# PFS timing PFICS_timing_xls

Schedule from MS Project, 2012-11-19 to 2013-01-03, 24 hours a day.

## Calendars

- 24 Hours: Mon-Sun 00:00-24:00.

## Resources

| Resource |
| --- |
| OBCP |
| PFICS |
| MCS |
| MPS |

## Schedule

| ID | WBS | Task | Duration | Start | Finish | Predecessors | Total slack | Free slack | Constraint | Resources | Work |
| --- | --- | --- | --- | --- | --- | --- | --- | --- | --- | --- | --- |
| 1 | 1 | close shutter | 2d | 2012-11-19 | 2012-11-21 |  | 0d |  | start no earlier than 2012-11-19 | OBCP | 48h |
| 2 | 2 | read out CCDs | 33d | 2012-11-21 | 2012-12-24 | 1 | 13.18d |  |  | OBCP | 792h |
| 3 | 3 | slew telescope and rotator | 7d | 2012-11-21 | 2012-11-28 | 1 | 0d |  |  | OBCP | 168h |
| 4 | 4 | **telescope settling & guider acquisition** | 20d | 2012-11-28 | 2012-12-18 | 3 | 16.58d |  |  | OBCP | 960h |
| 5 | 4.1 | settle telescope and rotator | 6d | 2012-11-28 | 2012-12-04 | 3 | 19.18d | 0d |  | OBCP | 144h |
| 6 | 4.2 | field acquisition | 7d | 2012-12-04 | 2012-12-11 | 5 | 19.18d | 0d |  | OBCP | 168h |
| 7 | 4.3 | autoguide and settle | 7d | 2012-12-11 | 2012-12-18 | 6 | 19.18d |  |  | OBCP | 168h |
| 8 | 5 | **fiber configuration** | 43.5d | 2012-11-21 | 2013-01-03 | 1 | 0d |  |  | PFICS | 2126.4h |
| 9 | 5.1 | Cobra home | 1.6d | 2012-11-21 | 2012-11-22 | 1 | 4.4d | 0d |  | MPS | 38.4h |
| 10 | 5.2 | MCS long exposure | 1d | 2012-11-22 | 2012-11-23 | 9 | 4.4d | 0d |  | MCS | 24h |
| 11 | 5.3 | MCS readout | 0.5d | 2012-11-23 | 2012-11-24 | 10 | 39.3d | 0d |  | MCS | 12h |
| 12 | 5.4 | MCS calibration & centroid | 0.5d | 2012-11-23 | 2012-11-24 | 11SS+0.1d | 39.3d | 0d |  | MCS | 12h |
| 13 | 5.5 | calculate distortion correction | 1d | 2012-11-24 | 2012-11-25 | 12 | 39.3d |  |  | PFICS | 24h |
| 14 | 5.6 | **Iteration 1** | 3.3d | 2012-11-28 | 2012-12-01 | 10, 3 | 0d |  |  |  | 88.8h |
| 15 | 5.6.1 | Cobra move | 1.6d | 2012-11-28 | 2012-11-29 | 10, 3 | 0d |  |  | MPS | 38.4h |
| 16 | 5.6.2 | MCS short exposure | 0.5d | 2012-11-29 | 2012-11-30 | 15 | 0d |  |  | MCS | 12h |
| 17 | 5.6.3 | MCS readout | 0.5d | 2012-11-30 | 2012-11-30 | 16 | 0d |  |  | MCS | 12h |
| 18 | 5.6.4 | MCS calibration & centroid | 0.5d | 2012-11-30 | 2012-11-30 | 17SS+0.1d | 0d |  |  | MCS | 12h |
| 19 | 5.6.5 | PFI calcs for new Cobra positions | 0.6d | 2012-11-30 | 2012-12-01 | 18 | 0d |  |  | PFICS | 14.4h |
| 20 | 5.7 | **Iteration 2** | 3.3d | 2012-12-01 | 2012-12-04 | 14 | 0d |  |  |  | 88.8h |
| 21 | 5.7.1 | Cobra move #2 | 1.6d | 2012-12-01 | 2012-12-02 | 19 | 0d |  |  | MPS | 38.4h |
| 22 | 5.7.2 | MCS short exposure | 0.5d | 2012-12-02 | 2012-12-03 | 21 | 0d |  |  | MCS | 12h |
| 23 | 5.7.3 | MCS readout | 0.5d | 2012-12-03 | 2012-12-03 | 22 | 0d |  |  | MCS | 12h |
| 24 | 5.7.4 | MCS calibration & centroid | 0.5d | 2012-12-03 | 2012-12-04 | 23SS+0.1d | 0d |  |  | MCS | 12h |
| 25 | 5.7.5 | PFI calcs for new Cobra positions | 0.6d | 2012-12-04 | 2012-12-04 | 24 | 0d |  |  | PFICS | 14.4h |

| ID | WBS | Task | Duration | Start | Finish | Predecessors | Total slack | Resources | Work |
| --- | --- | --- | --- | --- | --- | --- | --- | --- | --- |
| 26 | 5.8 | **Iteration 3** | 3.3d | 2012-12-04 | 2012-12-07 | 20 | 0d |  | 88.8h |
| 27 | 5.8.1 | Cobra move #3 | 1.6d | 2012-12-04 | 2012-12-06 | 25 | 0d | MPS | 38.4h |
| 28 | 5.8.2 | MCS short exposure | 0.5d | 2012-12-06 | 2012-12-06 | 27 | 0d | MCS | 12h |
| 29 | 5.8.3 | MCS readout | 0.5d | 2012-12-06 | 2012-12-07 | 28 | 0d | MCS | 12h |
| 30 | 5.8.4 | MCS calibration & centroid | 0.5d | 2012-12-06 | 2012-12-07 | 29SS+0.1d | 0d | MCS | 12h |
| 31 | 5.8.5 | PFI calcs for new Cobra positions | 0.6d | 2012-12-07 | 2012-12-07 | 30 | 0d | PFICS | 14.4h |
| 32 | 5.9 | **Iteration 4** | 3.8d | 2012-12-07 | 2012-12-11 | 26 | 0d |  | 100.8h |
| 33 | 5.9.1 | Cobra move #4 | 1.6d | 2012-12-07 | 2012-12-09 | 31 | 0d | MPS | 38.4h |
| 34 | 5.9.2 | MCS long exposure | 1d | 2012-12-09 | 2012-12-10 | 33 | 0d | MCS | 24h |
| 35 | 5.9.3 | MCS readout | 0.5d | 2012-12-10 | 2012-12-11 | 34 | 0d | MCS | 12h |
| 36 | 5.9.4 | MCS calibration & centroid | 0.5d | 2012-12-10 | 2012-12-11 | 35SS+0.1d | 0d | MCS | 12h |
| 37 | 5.9.5 | PFI calcs for new Cobra positions | 0.6d | 2012-12-11 | 2012-12-11 | 36 | 0d | PFICS | 14.4h |
| 38 | 5.10 | **Iteration 5** | 3.8d | 2012-12-11 | 2012-12-15 | 32 | 0d |  | 100.8h |
| 39 | 5.10.1 | Cobra move #5 | 1.6d | 2012-12-11 | 2012-12-13 | 37 | 0d | MPS | 38.4h |
| 40 | 5.10.2 | MCS long exposure | 1d | 2012-12-13 | 2012-12-14 | 39 | 0d | MCS | 24h |
| 41 | 5.10.3 | MCS readout | 0.5d | 2012-12-14 | 2012-12-14 | 40 | 0d | MCS | 12h |
| 42 | 5.10.4 | MCS calibration & centroid | 0.5d | 2012-12-14 | 2012-12-14 | 41SS+0.1d | 0d | MCS | 12h |
| 43 | 5.10.5 | PFI calcs for new Cobra positions | 0.6d | 2012-12-14 | 2012-12-15 | 42 | 0d | PFICS | 14.4h |
| 44 | 5.11 | **Iteration 6** | 3.8d | 2012-12-15 | 2012-12-19 | 38 | 0d |  | 100.8h |
| 45 | 5.11.1 | Cobra move #6 | 1.6d | 2012-12-15 | 2012-12-17 | 43 | 0d | MPS | 38.4h |
| 46 | 5.11.2 | MCS long exposure | 1d | 2012-12-17 | 2012-12-18 | 45 | 0d | MCS | 24h |
| 47 | 5.11.3 | MCS readout | 0.5d | 2012-12-18 | 2012-12-18 | 46 | 0d | MCS | 12h |
| 48 | 5.11.4 | MCS calibration & centroid | 0.5d | 2012-12-18 | 2012-12-18 | 47SS+0.1d | 0d | MCS | 12h |
| 49 | 5.11.5 | PFI calcs for new Cobra positions | 0.6d | 2012-12-18 | 2012-12-19 | 48 | 0d | PFICS | 14.4h |

| ID | WBS | Task | Duration | Start | Finish | Predecessors | Total slack | Resources | Work |
| --- | --- | --- | --- | --- | --- | --- | --- | --- | --- |
| 50 | 5.12 | **Iteration 7** | 3.8d | 2012-12-19 | 2012-12-23 | 44 | 0d |  | 100.8h |
| 51 | 5.12.1 | Cobra move #7 | 1.6d | 2012-12-19 | 2012-12-20 | 49 | 0d | MPS | 38.4h |
| 52 | 5.12.2 | MCS long exposure | 1d | 2012-12-20 | 2012-12-21 | 51 | 0d | MCS | 24h |
| 53 | 5.12.3 | MCS readout | 0.5d | 2012-12-21 | 2012-12-22 | 52 | 0d | MCS | 12h |
| 54 | 5.12.4 | MCS calibration & centroid | 0.5d | 2012-12-22 | 2012-12-22 | 53SS+0.1d | 0d | MCS | 12h |
| 55 | 5.12.5 | PFI calcs for new Cobra positions | 0.6d | 2012-12-22 | 2012-12-23 | 54 | 0d | PFICS | 14.4h |
| 56 | 5.13 | **Iteration 8** | 3.8d | 2012-12-23 | 2012-12-26 | 50 | 0d |  | 100.8h |
| 57 | 5.13.1 | Cobra move #8 | 1.6d | 2012-12-23 | 2012-12-24 | 55 | 0d | MPS | 38.4h |
| 58 | 5.13.2 | MCS long exposure | 1d | 2012-12-24 | 2012-12-25 | 57 | 0d | MCS | 24h |
| 59 | 5.13.3 | MCS readout | 0.5d | 2012-12-25 | 2012-12-26 | 58 | 0d | MCS | 12h |
| 60 | 5.13.4 | MCS calibration & centroid | 0.5d | 2012-12-25 | 2012-12-26 | 59SS+0.1d | 0d | MCS | 12h |
| 61 | 5.13.5 | PFI calcs for new Cobra positions | 0.6d | 2012-12-26 | 2012-12-26 | 60 | 0d | PFICS | 14.4h |
| 62 | 5.14 | **Iteration 9** | 3.8d | 2012-12-26 | 2012-12-30 | 56 | 0d |  | 100.8h |
| 63 | 5.14.1 | Cobra move #9 | 1.6d | 2012-12-26 | 2012-12-28 | 61 | 0d | MPS | 38.4h |
| 64 | 5.14.2 | MCS long exposure | 1d | 2012-12-28 | 2012-12-29 | 63 | 0d | MCS | 24h |
| 65 | 5.14.3 | MCS readout | 0.5d | 2012-12-29 | 2012-12-30 | 64 | 0d | MCS | 12h |
| 66 | 5.14.4 | MCS calibration & centroid | 0.5d | 2012-12-29 | 2012-12-30 | 65SS+0.1d | 0d | MCS | 12h |
| 67 | 5.14.5 | PFI calcs for new Cobra positions | 0.6d | 2012-12-30 | 2012-12-30 | 66 | 0d | PFICS | 14.4h |
| 68 | 5.15 | **Iteration 10** | 3.8d | 2012-12-30 | 2013-01-03 | 62 | 0d |  | 100.8h |
| 69 | 5.15.1 | Cobra move #10 | 1.6d | 2012-12-30 | 2013-01-01 | 67 | 0d | MPS | 38.4h |
| 70 | 5.15.2 | MCS long exposure | 1d | 2013-01-01 | 2013-01-02 | 69 | 0d | MCS | 24h |
| 71 | 5.15.3 | MCS readout | 0.5d | 2013-01-02 | 2013-01-02 | 70 | 0d | MCS | 12h |
| 72 | 5.15.4 | MCS calibration & centroid | 0.5d | 2013-01-02 | 2013-01-02 | 71SS+0.1d | 0d | MCS | 12h |
| 73 | 5.15.5 | PFI calcs for new Cobra positions | 0.6d | 2013-01-02 | 2013-01-03 | 72 | 0d | PFICS | 14.4h |
| 74 | 6 | open shutter | 2h | 2013-01-03 | 2013-01-03 | 8, 73, 68 | 0d | OBCP | 2h |
